# Lançamento Comercial de produto

Schedule from MS Project, 2006-11-24 to 2007-02-04, costs in R$.
Objetivo didático
UFPE
Projeto de exemplo para fixação do / treinamento

## Calendars

- Standard: Mon-Fri 08:00-12:00, 13:00-17:00; Sat-Sun off.
- Reuniões: Mon-Fri 08:00-12:00, 13:00-22:00; Sat-Sun off. Exceptions (off unless hours are given): 2006-12-08, 2006-12-21 08:00-12:00, 13:00-22:00, 2006-12-23, 2006-12-25, 2006-12-26 08:00-12:00, 13:00-22:00, 2006-12-28 08:00-12:00, 13:00-22:00, 2006-12-30 to 2007-01-01.

## Resources

| Resource | Group | Unit | Rate | Cost per use |
| --- | --- | --- | --- | --- |
| Diretor Trabalho | DIR |  | 50 |  |
| Secretária | DIR |  | 12 |  |
| Ger. Executivo | PRO |  | 18 |  |
| Ger. Administrativo | ADM |  | 16 |  |
| Produção | PRO |  | 6 |  |
| Quimico | PRO |  | 12 |  |
| Distribuidor | MKT |  |  |  |
| Ag. Publicidade | MKT |  |  |  |
| Vendedor | MKT |  | 8 |  |
| Caminhao | EQP |  | 3 |  |
| Motorista | PRO |  | 12 |  |
| Ajudante | PRO |  | 4 |  |
| Reagente | MAT | Galões | 1.3 |  |
| Kit de Limpeza | MAT | Conjuntos |  | 800 |

## Schedule

| ID | WBS | Task | Type | Duration | Start | Finish | Predecessors | Total slack | Free slack | Constraint | Calendar | Resources | Work | Cost |
| --- | --- | --- | --- | --- | --- | --- | --- | --- | --- | --- | --- | --- | --- | --- |
| 1 | 1 | **Lançamento Comercial de produto** |  | 51d | 2006-11-24 | 2007-02-04 |  | 0d |  |  |  |  | 17334h | 109,617.95 |
| 2 | 1.1 | **Rotinas da Administração** |  | 51d | 2006-11-24 | 2007-02-04 |  | 0d |  |  |  |  | 4526h | 29,744 |
| 3 | 1.1.1 | Comunicar Metas |  | 4h | 2006-11-24 | 2006-11-24 |  | 0.5d | 0d |  |  | Diretor Trabalho [300%]; Secretária [300%]; Ger. Executivo; Ger. Administrativo | 32h | 880 |
| 4 | 1.1.2 | Providenciar Registro |  | 7.25d | 2006-11-24 | 2006-12-05 | 3 | 39.36d | 20.25d |  |  | Ger. Administrativo; Secretária | 72h | 1,008 |
| 5 | 1.1.3 | Contatar Veículo Propaganda |  | 3d | 2006-11-24 | 2006-11-29 | 3 | 41.61d | 0d |  |  | Secretária | 24h | 288 |
| 6 | 1.1.4 | Comprar Material de Propaganda |  | 3d | 2006-11-24 | 2006-11-29 | 3 | 41.61d | 0d |  |  | Secretária; Ger. Administrativo | 32h | 528 |
| 7 | 1.1.5 | Discutir Vendas |  | 3.5d | 2006-11-29 | 2006-12-01 | 5, 6 | 62.98d | 22.5d |  | Reuniões | Secretária; Distribuidor [10000%]; Vendedor [1200%] | 3164h | 3,024 |
| 8 | 1.1.6 | Reavaliar Processos |  | 4h | 2007-01-03 | 2007-01-03 | 4, 7, 25 | 19.11d | 0d |  |  | Diretor Trabalho [200%]; Secretária [200%]; Ger. Executivo | 20h | 568 |
| 9 | 1.1.7 | Discutir Lançamento |  | 12h | 2007-01-03 | 2007-01-04 | 8 | 30.98d | 19.11d |  | Reuniões | Diretor Trabalho [300%]; Secretária [300%]; Ger. Executivo; Ger. Administrativo | 96h | 2,640 |
| 10 | 1.1.8 | Conferir material propaganda |  | 6h | 2006-11-29 | 2006-11-30 | 6 | 42.48d | 0d |  |  | Secretária | 6h | 72 |
| 11 | 1.1.9 | Distribuir material propaganda |  | 2d | 2006-11-30 | 2006-12-02 | 10 | 42.48d |  |  |  | Motorista [1200%]; Caminhao [1200%] | 384h | 2,880 |
| 12 | 1.1.10 | Veicular comercial |  | 3d | 2007-01-26 | 2007-01-31 | 5 | 0d |  | as late as possible |  | Ag. Publicidade | 24h |  |
| 13 | 1.1.11 | Lançar Produto |  | 4ed | 2007-01-31 | 2007-02-04 | 9, 11, 12, 21 | 0d |  |  |  | Diretor Trabalho [300%]; Secretária [300%]; Ag. Publicidade | 672h | 17,856 |
| 14 | 1.2 | **Rotinas de Produção** |  | 48.23d | 2006-11-24 | 2007-01-31 |  | 0d |  |  |  |  | 12808h | 79,873.95 |
| 15 | 1.2.1 | Produzir Protótipo |  | 5.75d | 2006-11-24 | 2006-12-01 | 3 | 0.5d | 0d |  |  | Ger. Executivo; Produção [2500%] | 1040h | 6,720 |
| 16 | 1.2.2 | Produzir Produto |  | 14d | 2006-12-29 | 2007-01-17 | 24 | 0d |  |  |  | Produção [8000%] | 8960h | 53,760 |
| 17 | 1.2.3 | Produzir Embalagem |  | 4d | 2007-01-22 | 2007-01-26 | 16SS | 0d |  |  |  | Produção [4000%] | 1280h | 7,680 |
| 18 | 1.2.4 | Pronto para Embalar | milestone | 0d | 2007-01-26 | 2007-01-26 | 16, 17 | 0d |  |  |  |  |  |  |
| 19 | 1.2.5 | Embalar |  | 0.23d | 2007-01-26 | 2007-01-26 | 18 | 0d |  |  |  | Ger. Executivo; Produção [2500%] | 48h | 310.15 |
| 20 | 1.2.6 | Carregar |  | 2d | 2007-01-26 | 2007-01-29 | 19 | 0d |  |  |  | Caminhao [1200%]; Motorista [1200%]; Ajudante [1200%] | 576h | 3,648 |
| 21 | 1.2.7 | Distribuir |  | 2d | 2007-01-29 | 2007-01-31 | 20 | 0d |  |  |  | Caminhao [1200%]; Motorista [1200%]; Ajudante [1200%]; Vendedor [1200%] | 768h | 5,184 |
| 22 | 1.2.8 | **Teste de Qualidade** |  | 23d | 2006-12-01 | 2007-01-03 |  | 0.75d |  |  |  |  | 136h | 2,571.8 |
| 23 | 1.2.8.1 | Colher/testar Amostra |  | 6h | 2006-12-01 | 2006-12-01 | 15 | 0d |  |  |  | Ger. Executivo; Quimico [300%]; Reagente [6 Galões]; Kit de Limpeza [1 Conjuntos] | 24h | 1,131.8 |
| 24 | 1.2.8.2 | Analisar Resultados |  | 2d | 2006-12-28 | 2006-12-29 | 23FS+18d | 0d |  |  |  | Quimico [300%] | 48h | 576 |
| 25 | 1.2.8.3 | Redigir Relatório Técnico |  | 2d | 2006-12-29 | 2007-01-03 | 24 | 19.11d | 0d |  |  | Ger. Executivo; Quimico [300%] | 64h | 864 |
