# Lançamento Comercial de produto

Schedule from MS Project, 2006-11-13 to 2007-01-30, costs in R$.
Objetivo didático
UFPE
Projeto de exemplo para fixação do / treinamento

## Calendars

- Standard: Mon-Fri 08:00-12:00, 13:00-17:00; Sat-Sun off. Exceptions (off unless hours are given): 2006-11-21 08:00-12:00, 14:00-18:00.
- Reuniões: Mon-Fri 08:00-12:00, 13:00-22:00; Sat-Sun off. Exceptions (off unless hours are given): 2006-11-15, 2006-11-21 08:00-12:00, 14:00-22:00, 2006-11-23 08:00-12:00, 13:00-22:00, 2006-12-08, 2006-12-21 08:00-12:00, 13:00-22:00, 2006-12-23, 2006-12-25, 2006-12-26 08:00-12:00, 13:00-22:00, 2006-12-28 08:00-12:00, 13:00-22:00, 2006-12-30 to 2007-01-01.

## Resources

| Resource | Group | Unit | Rate | Cost per use |
| --- | --- | --- | --- | --- |
| Diretor Trabalho | DIR |  | 50 |  |
| Secretária | DIR |  | 12 |  |
| Ger. Executivo | PRO |  | 18 |  |
| Ger. Administrativo | ADM |  | 16 |  |
| Produção | PRO |  | 6 |  |
| Quimico | PRO |  | 12 |  |
| Distribuidor | MKT |  |  |  |
| Ag. Publicidade | MKT |  |  |  |
| Vendedor | MKT |  | 8 |  |
| Caminhao | EQP |  | 3 |  |
| Motorista | PRO |  | 12 |  |
| Ajudante | PRO |  | 4 |  |
| Reagente | MAT | Galões | 1.3 |  |
| Kit de Limpeza | MAT | Conjuntos |  | 800 |

## Schedule

| ID | WBS | Task | Type | Duration | Start | Finish | Predecessors | Total slack | Free slack | Constraint | Calendar | Resources | Work | Cost |
| --- | --- | --- | --- | --- | --- | --- | --- | --- | --- | --- | --- | --- | --- | --- |
| 1 | 1 | **Lançamento Comercial de produto** |  | 56.73d | 2006-11-13 | 2007-01-30 |  | 0d |  |  |  |  | 17102h | 129,985.95 |
| 2 | 1.1 | **Rotinas da Administração** |  | 56.73d | 2006-11-13 | 2007-01-30 |  | 0d |  |  |  |  | 4502h | 51,456 |
| 3 | 1.1.1 | Comunicar Metas |  | 4h | 2006-11-13 | 2006-11-13 |  | 0d |  |  |  | Diretor Trabalho [300%]; Secretária [300%]; Ger. Executivo; Ger. Administrativo | 32h | 880 |
| 4 | 1.1.2 | Providenciar Registro |  | 7d | 2006-11-14 | 2006-11-23 | 3 | 44.36d | 18.25d |  |  | Ger. Administrativo; Secretária | 72h | 1,008 |
| 5 | 1.1.3 | Contatar Veículo Propaganda |  | 3d | 2006-11-14 | 2006-11-17 | 3 | 45d | 0d |  |  | Secretária | 24h | 288 |
| 6 | 1.1.4 | Comprar Material de Propaganda |  | 3d | 2006-11-13 | 2006-11-17 | 3 | 45.5d | 0d |  |  | Secretária; Ger. Administrativo | 32h | 528 |
| 7 | 1.1.5 | Discutir Vendas |  | 3.5d | 2006-11-21 | 2006-11-23 | 5, 6 | 68.23d | 18.88d |  | Reuniões | Secretária; Distribuidor [10000%]; Vendedor [1200%] | 3164h | 3,024 |
| 8 | 1.1.6 | Reavaliar Processos |  | 4h | 2006-12-20 | 2006-12-20 | 4, 7, 25 | 26.11d | 0d |  |  | Diretor Trabalho [200%]; Secretária [200%]; Ger. Executivo | 20h | 568 |
| 9 | 1.1.7 | Discutir Lançamento |  | 12h | 2006-12-20 | 2006-12-21 | 8 | 39.11d | 26.11d |  | Reuniões | Diretor Trabalho [300%]; Secretária; Ger. Executivo; Ger. Administrativo | 72h | 2,352 |
| 10 | 1.1.8 | Conferir material propaganda |  | 6h | 2006-11-17 | 2006-11-20 | 6 | 46.98d | 0d |  |  | Secretária | 6h | 2,572 |
| 11 | 1.1.9 | Distribuir material propaganda |  | 2d | 2006-11-20 | 2006-11-22 | 10 | 46.98d |  |  |  | Motorista [1200%]; Caminhao [1200%] | 384h | 2,880 |
| 12 | 1.1.10 | Veicular comercial |  | 3d | 2007-01-23 | 2007-01-26 | 5 | 0d |  | as late as possible |  | Ag. Publicidade | 24h | 12,000 |
| 13 | 1.1.11 | Lançar Produto |  | 4ed | 2007-01-26 | 2007-01-30 | 9, 11, 12, 21 | 0d |  |  |  | Diretor Trabalho [300%]; Secretária [300%]; Ag. Publicidade | 672h | 25,356 |
| 14 | 1.2 | **Rotinas de Produção** |  | 54.23d | 2006-11-13 | 2007-01-26 |  | 0d |  |  |  |  | 12600h | 78,529.95 |
| 15 | 1.2.1 | Produzir Protótipo |  | 4.5d | 2006-11-13 | 2006-11-18 | 3 | 0d |  |  |  | Ger. Executivo; Produção [2500%] | 832h | 5,376 |
| 16 | 1.2.2 | Produzir Produto |  | 14d | 2006-12-18 | 2007-01-22 | 24 | 0d |  |  |  | Produção [8000%] | 8960h | 53,760 |
| 17 | 1.2.3 | Produzir Embalagem |  | 8d | 2006-12-18 | 2006-12-28 | 16SS | 17.25d |  |  |  | Produção [2000%] | 1280h | 7,680 |
| 18 | 1.2.4 | Pronto para Embalar | milestone | 0d | 2007-01-22 | 2007-01-22 | 16, 17 | 0d |  |  |  |  |  |  |
| 19 | 1.2.5 | Embalar |  | 0.23d | 2007-01-22 | 2007-01-22 | 18 | 0d |  |  |  | Ger. Executivo; Produção [2500%] | 48h | 310.15 |
| 20 | 1.2.6 | Carregar |  | 2d | 2007-01-22 | 2007-01-24 | 19 | 0d |  |  |  | Caminhao [1200%]; Motorista [1200%]; Ajudante [1200%] | 576h | 3,648 |
| 21 | 1.2.7 | Distribuir |  | 2d | 2007-01-24 | 2007-01-26 | 20 | 0d |  |  |  | Caminhao [1200%]; Motorista [1200%]; Ajudante [1200%]; Vendedor [1200%] | 768h | 5,184 |
| 22 | 1.2.8 | **Teste de Qualidade** |  | 22.25d | 2006-11-20 | 2006-12-20 |  | 0d |  |  |  |  | 136h | 2,571.8 |
| 23 | 1.2.8.1 | Colher/testar Amostra |  | 10h | 2006-11-20 | 2006-11-21 | 15 | 0d |  |  |  | Ger. Executivo; Quimico [300%]; Reagente [6 Galões]; Kit de Limpeza [1 Conjuntos] | 24h | 1,131.8 |
| 24 | 1.2.8.2 | Analisar Resultados |  | 2d | 2006-12-15 | 2006-12-18 | 23FS+18d | 0d |  |  |  | Quimico [300%] | 48h | 576 |
| 25 | 1.2.8.3 | Redigir Relatório Técnico |  | 2d | 2006-12-18 | 2006-12-20 | 24 | 26.11d | 0d |  |  | Ger. Executivo; Quimico [300%] | 64h | 864 |
